# Implementering af Webside

Schedule from MS Project, 2007-09-10 to 2007-12-12, costs in kr, A marks actual dates.
4D Konsulenterne A/S

## Calendars

- Standard: Mon-Fri 08:00-12:00, 13:00-17:00; Sat-Sun off.

## Resources

| Resource | Rate | Cost per use |
| --- | --- | --- |
| Peter Wulf | 575 | 500 |
| Søren Novotny | 345 | 500 |
| Mikker Junker | 266 |  |
| Thomas Riis | 455 | 500 |
| Lars Thorsen | 175 |  |
| Jon Rosengård | 28 |  |
| Brian Adel | 203 |  |
| Morten Borre | 450 |  |
| Peter Kastrup | 566 |  |

## Schedule

| ID | WBS | Task | Type | Duration | Start | Finish | Predecessors | Complete | Remaining | Total slack | Free slack | Resources | Work | Actual work | Cost | Actual cost |
| --- | --- | --- | --- | --- | --- | --- | --- | --- | --- | --- | --- | --- | --- | --- | --- | --- |
| 1 | 1 | **Implementering af WEB side** |  | 68d? | 2007-09-10 A | 2007-12-12 |  | 33% | 45.88d? | 0d |  |  | 1912h | 544h | 561,072 | 147,450 |
| 2 | 1.1 | **Koncept** |  | 18d | 2007-09-10 A | 2007-10-03 |  | 96% | 0.69d | 50d |  |  | 208h | 200h | 74,612 | 70,472 |
| 3 | 1.1.1 | Evaluere de aktuelle systemer |  | 5d | 2007-09-10 A | 2007-09-14 A |  | 100% |  |  |  | Peter Wulf | 40h | 40h | 23,500 | 23,500 |
| 4 | 1.1.2 | **Definition af krav** |  | 5d | 2007-09-17 A | 2007-09-21 A | 3 | 100% |  |  |  |  | 104h | 104h | 19,992 | 19,992 |
| 5 | 1.1.2.1 | Definere brugerkrav |  | 5d | 2007-09-17 A | 2007-09-21 A |  | 100% |  |  |  | Brian Adel | 40h | 40h | 8,120 | 8,120 |
| 6 | 1.1.2.2 | Definere indholdskrav |  | 3d | 2007-09-17 A | 2007-09-19 A | 3 | 100% |  |  |  | Brian Adel | 24h | 24h | 4,872 | 4,872 |
| 7 | 1.1.2.3 | Definere systemkrav |  | 3d | 2007-09-17 A | 2007-09-19 A | 3 | 100% |  |  |  | Lars Thorsen | 24h | 24h | 4,200 | 4,200 |
| 8 | 1.1.2.4 | Definere ejerkrav til server |  | 2d | 2007-09-17 A | 2007-09-18 A | 3 | 100% |  |  |  | Lars Thorsen | 16h | 16h | 2,800 | 2,800 |
| 9 | 1.1.3 | Definere bestemte funktioner |  | 1d | 2007-09-24 A | 2007-09-24 A | 5, 8, 7 | 100% |  |  |  | Thomas Riis | 8h | 8h | 4,140 | 4,140 |
| 10 | 1.1.4 | Definere risici og risikostyringsmetode |  | 4d | 2007-09-25 A | 2007-09-28 A | 9 | 100% |  |  |  | Thomas Riis | 32h | 32h | 15,060 | 15,060 |
| 11 | 1.1.5 | Oprette projektplan |  | 2d | 2007-10-01 A | 2007-10-02 A | 10 | 100% |  |  |  | Thomas Riis | 16h | 16h | 7,780 | 7,780 |
| 12 | 1.1.6 | Underrette Web-udviklingsgruppe |  | 1d | 2007-10-03 | 2007-10-03 | 11 |  |  | 50d |  | Thomas Riis | 8h |  | 4,140 |  |
| 13 | 1.2 | **Design af Web-sted** |  | 22d? | 2007-10-04 A | 2007-11-02 |  | 50% | 11d? | 28d |  |  | 224h | 112h | 74,128 | 27,992 |
| 14 | 1.2.1 | **Design af brugergrænseflade** |  | 12d? | 2007-10-04 A | 2007-10-19 |  | 93% | 0.8d? | 0d |  |  | 120h | 112h | 29,392 | 27,992 |
| 15 | 1.2.1.1 | Fastlægge Web-stedets layout |  | 8d? | 2007-10-04 A | 2007-10-15 A | 2, 12 | 100% |  |  |  | Brian Adel | 64h | 64h | 12,992 | 12,992 |
| 16 | 1.2.1.2 | Fastlægge datakæder |  | 4d | 2007-10-16 A | 2007-10-19 | 15 | 75% | 1d | 0d |  | Lars Thorsen | 32h | 24h | 5,600 | 4,200 |
| 17 | 1.2.1.3 | Fastlægge, hvordan funktionerne skal implementeres |  | 3d | 2007-10-16 A | 2007-10-18 A | 15 | 100% |  |  |  | Morten Borre | 24h | 24h | 10,800 | 10,800 |
| 18 | 1.2.1.4 | Design færdiggjort | milestone | 0d | 2007-10-19 | 2007-10-19 | 16, 17 |  |  | 0d |  |  |  |  |  |  |
| 19 | 1.2.2 | **Design af serveropsætning** |  | 6d | 2007-10-22 | 2007-10-29 | 18 |  |  | 0d |  |  | 56h |  | 23,496 |  |
| 20 | 1.2.2.1 | Fastlægge det anslåede forbrug af diskplads |  | 0.5d | 2007-10-22 | 2007-10-22 |  |  |  | 0.5d |  | Lars Thorsen | 4h |  | 700 |  |
| 21 | 1.2.2.2 | Fastlægge den anslåede trafik |  | 0.5d | 2007-10-22 | 2007-10-22 |  |  |  | 0.5d |  | Brian Adel | 4h |  | 812 |  |
| 22 | 1.2.2.3 | Designe adgangstilladelse |  | 1d | 2007-10-22 | 2007-10-22 |  |  |  | 0d |  | Mikker Junker | 8h |  | 2,128 |  |
| 23 | 1.2.2.4 | Designe skema med test- og opsætningsomfang |  | 3d | 2007-10-23 | 2007-10-25 | 20, 21, 22 |  |  | 0d |  | Morten Borre | 24h |  | 10,800 |  |
| 24 | 1.2.2.5 | Kommunikere med serverhandlinger |  | 2d | 2007-10-26 | 2007-10-29 | 23 |  |  | 32d | 0d | Peter Kastrup | 16h |  | 9,056 |  |
| 25 | 1.2.2.6 | Server-sted installeret | milestone | 0d | 2007-10-29 | 2007-10-29 | 24 |  |  | 32d |  |  |  |  |  |  |

| ID | WBS | Task | Type | Duration | Start | Finish | Predecessors | Complete | Remaining | Total slack | Free slack | Resources | Work | Actual work | Cost | Actual cost |
| --- | --- | --- | --- | --- | --- | --- | --- | --- | --- | --- | --- | --- | --- | --- | --- | --- |
| 26 | 1.2.3 | **Udvikling af infrastruktur for serversupport** |  | 6d | 2007-10-26 | 2007-11-02 |  |  |  | 0d |  |  | 48h |  | 21,240 |  |
| 27 | 1.2.3.1 | Fastlægge virkning på netværk |  | 2d | 2007-10-26 | 2007-10-29 | 23 |  |  | 0d |  | Lars Thorsen | 16h |  | 2,800 |  |
| 28 | 1.2.3.2 | Fastlægge, hvilke ændringer der skal foretages |  | 3d | 2007-10-30 | 2007-11-01 | 27 |  |  | 0d |  | Peter Wulf | 24h |  | 14,300 |  |
| 29 | 1.2.3.3 | Kommunikere med supportgruppen |  | 1d | 2007-11-02 | 2007-11-02 | 28 |  |  | 0d |  | Thomas Riis | 8h |  | 4,140 |  |
| 30 | 1.2.3.4 | Supportkrav opfyldt | milestone | 0d | 2007-11-02 | 2007-11-02 | 29 |  |  | 0d |  |  |  |  |  |  |
| 31 | 1.3 | **Udvikling af Web-sted** |  | 55d? | 2007-09-20 A | 2007-12-05 |  | 29% | 39.21d? | 0d |  |  | 1048h | 232h | 257,472 | 48,986 |
| 32 | 1.3.1 | **Oprettelse af sider og hyperlinks** |  | 18d | 2007-10-22 A | 2007-11-14 |  | 4% | 17.29d | 1d |  |  | 392h | 6h | 105,728 | 2,570 |
| 33 | 1.3.1.1 | Oprette HTML-typografiskabelon |  | 3d | 2007-10-22 A | 2007-10-24 | 18 | 25% | 2.25d | 1d | 0d | Søren Novotny | 24h | 6h | 8,780 | 2,570 |
| 34 | 1.3.1.2 | Fastlægge udviklingsværktøj |  | 1d | 2007-10-22 | 2007-10-22 | 18 |  |  | 3d | 2d | Mikker Junker | 8h |  | 2,128 |  |
| 35 | 1.3.1.3 | Udvikling |  | 15d | 2007-10-25 | 2007-11-14 | 33, 34 |  |  | 1d | 0d | Søren Novotny; Mikker Junker; Lars Thorsen | 360h |  | 94,820 |  |
| 36 | 1.3.2 | **Udviklingsfunktioner** |  | 22d | 2007-10-22 A | 2007-11-20 |  | 20% | 17.66d | 3d |  |  | 152h | 30h | 4,256 | 840 |
| 37 | 1.3.2.1 | Oprette evt. brugerdefinerede funktioner |  | 15d | 2007-10-22 A | 2007-11-09 | 18 | 25% | 11.25d | 6d | 3d | Jon Rosengård | 120h | 30h | 3,360 | 840 |
| 38 | 1.3.2.2 | Integrere i Web-sted |  | 4d | 2007-11-15 | 2007-11-20 | 35, 37 |  |  | 3d |  | Jon Rosengård | 32h |  | 896 |  |
| 39 | 1.3.3 | **Overførsel/integration af oplysninger** |  | 27d? | 2007-09-20 A | 2007-10-26 |  | 91% | 2.5d? | 20d |  |  | 216h | 196h | 52,476 | 45,576 |
| 40 | 1.3.3.1 | Fastlægge, hvilke oplysninger der skal flyttes/konverteres |  | 3d | 2007-09-20 A | 2007-09-24 A | 6 | 100% |  |  |  | Brian Adel | 24h | 24h | 4,872 | 4,872 |
| 41 | 1.3.3.2 | Prioritere konvertering af oplysninger |  | 2d | 2007-09-25 A | 2007-09-26 A | 40 | 100% |  |  |  | Brian Adel | 16h | 16h | 3,248 | 3,248 |
| 42 | 1.3.3.3 | Angive standarder for konvertering af oplysninger |  | 2d | 2007-09-27 A | 2007-09-28 A | 41 | 100% |  |  |  | Peter Kastrup | 16h | 16h | 9,056 | 9,056 |
| 43 | 1.3.3.4 | Implementere overførsel og konvertering af oplysninger |  | 15d? | 2007-10-01 A | 2007-10-19 A | 42 | 100% |  |  |  | Lars Thorsen | 120h | 120h | 21,000 | 21,000 |
| 44 | 1.3.3.5 | Teste konverteringsformater |  | 5d | 2007-10-22 A | 2007-10-26 | 43 | 50% | 2.5d | 20d |  | Søren Novotny | 40h | 20h | 14,300 | 7,400 |
| 45 | 1.3.4 | **Test** |  | 23d? | 2007-11-05 | 2007-12-05 |  |  |  | 0d |  |  | 288h |  | 95,012 |  |
| 46 | 1.3.4.1 | Oprette testplan |  | 4d | 2007-11-05 | 2007-11-08 | 30 |  |  | 0d |  | Peter Kastrup | 32h |  | 18,112 |  |
| 47 | 1.3.4.2 | Teste sider |  | 10d? | 2007-11-09 | 2007-11-22 | 35SS+10d, 46 |  |  | 0d |  | Jon Rosengård | 80h |  | 2,240 |  |
| 48 | 1.3.4.3 | Teste hyperlinks |  | 6d | 2007-11-16 | 2007-11-23 | 47FS-5d |  |  | 0d |  | Søren Novotny | 48h |  | 17,060 |  |
| 49 | 1.3.4.4 | Teste brugervenlighed |  | 8d | 2007-11-26 | 2007-12-05 | 35, 38, 44, 46, 47, 48 |  |  | 0d |  | Morten Borre | 64h |  | 28,800 |  |
| 50 | 1.3.4.5 | Teste belastning |  | 8d | 2007-11-26 | 2007-12-05 | 35, 38, 44, 46, 47, 48 |  |  | 0d |  | Morten Borre | 64h |  | 28,800 |  |

| ID | WBS | Task | Type | Duration | Start | Finish | Predecessors | Total slack | Free slack | Resources | Work | Cost |
| --- | --- | --- | --- | --- | --- | --- | --- | --- | --- | --- | --- | --- |
| 51 | 1.4 | **Installation** |  | 25d? | 2007-11-08 | 2007-12-12 |  | 0d |  |  | 296h | 90,708 |
| 52 | 1.4.1 | Flytte sted til den offentlige server |  | 2d | 2007-11-26 | 2007-11-27 | 35, 38, 44, 46, 47, 48 | 11d |  | Jon Rosengård | 16h | 448 |
| 53 | 1.4.2 | Fastlægge installationsplan |  | 5d | 2007-11-08 | 2007-11-14 | 31FS-20d | 0d |  | Jon Rosengård | 40h | 1,120 |
| 54 | 1.4.3 | Kommunikere installationsplan til brugere |  | 10d | 2007-11-15 | 2007-11-28 | 53 | 0d |  | Thomas Riis | 80h | 36,900 |
| 55 | 1.4.4 | Forestå brugerundervisning |  | 10d? | 2007-11-15 | 2007-11-28 | 53 | 0d |  | Brian Adel | 80h | 16,240 |
| 56 | 1.4.5 | Udsende intern pressemeddelelse |  | 10d | 2007-11-15 | 2007-11-28 | 53 | 0d |  | Morten Borre | 80h | 36,000 |
| 57 | 1.4.6 | Web-sted installeret | milestone | 0d | 2007-12-12 | 2007-12-12 | 54FS+10d, 55FS+10d, 56FS+10d | 0d |  |  |  |  |
| 58 | 1.5 | **Support** |  | 28d | 2007-11-05 | 2007-12-12 |  | 0d |  |  | 136h | 64,152 |
| 59 | 1.5.1 | Fastlægge, hvilke supportressourcer der er nødvendige |  | 4d | 2007-11-05 | 2007-11-08 | 30 | 11d | 0d | Mikker Junker | 32h | 8,512 |
| 60 | 1.5.2 | Foretage ændringer i personalesammensætning |  | 5d | 2007-11-09 | 2007-11-15 | 59 | 11d | 0d | Peter Kastrup | 40h | 22,640 |
| 61 | 1.5.3 | Fastlægge supportmetode for brugerne |  | 3d | 2007-11-16 | 2007-11-20 | 60 | 11d | 0d | Peter Wulf | 24h | 14,300 |
| 62 | 1.5.4 | Fastlægge supportproces |  | 5d | 2007-11-21 | 2007-11-27 | 61 | 11d |  | Thomas Riis | 40h | 18,700 |
| 63 | 1.5.5 | Support etableret | milestone | 0d | 2007-12-12 | 2007-12-12 | 57 | 0d |  |  |  |  |
