# Butik i Århus

Schedule from MS Project, 2007-09-10 to 2007-10-15, costs in kr.
VideoBuster A/S
Projektplan over byggeriet af den nye butik i Århus. Butikken forventes klar til indvielse om to måneder.

## Calendars

- Standard: Mon-Fri 08:00-12:00, 13:00-17:00; Sat-Sun off.

## Schedule

| ID | WBS | Task | Type | Duration | Start | Finish | Predecessors | Total slack | Free slack | Cost |
| --- | --- | --- | --- | --- | --- | --- | --- | --- | --- | --- |
| 1 | 1 | **Ny butik i Århus** |  | 26d | 2007-09-10 | 2007-10-15 |  | 0d |  | 36,000 |
| 2 | 1.1 | Tegning |  | 3d | 2007-09-10 | 2007-09-12 |  | 0d |  |  |
| 3 | 1.2 | **Fundament** |  | 8d | 2007-09-13 | 2007-09-24 | 2 | 0d |  | 1,000 |
| 4 | 1.2.1 | Udgravning |  | 2d | 2007-09-13 | 2007-09-14 |  | 0d |  |  |
| 5 | 1.2.2 | Støbning |  | 1d | 2007-09-17 | 2007-09-17 | 4 | 0d |  | 1,000 |
| 6 | 1.2.3 | Afbinding |  | 5d | 2007-09-18 | 2007-09-24 | 5 | 0d |  |  |
| 7 | 1.3 | **Råhus** |  | 5d | 2007-09-25 | 2007-10-01 | 6 | 0d |  | 35,000 |
| 8 | 1.3.1 | Bærende konstruktioner |  | 3d | 2007-09-25 | 2007-09-27 |  | 0d |  |  |
| 9 | 1.3.2 | Ydervægge |  | 2d | 2007-09-28 | 2007-10-01 | 8 | 0d |  | 15,000 |
| 10 | 1.3.3 | Tag |  | 2d | 2007-09-28 | 2007-10-01 | 9SS | 0d |  | 20,000 |
| 11 | 1.4 | Rejsegilde | milestone | 0d | 2007-10-01 | 2007-10-01 | 10 | 0d |  |  |
| 12 | 1.5 | Taglægning |  | 10d | 2007-10-02 | 2007-10-15 | 11 | 0d |  |  |
| 13 | 1.6 | Døre og vinduer |  | 2d | 2007-10-02 | 2007-10-03 | 12SS | 5.12d | 0d |  |
| 14 | 1.7 | Faskine |  | 2d | 2007-09-17 | 2007-09-18 | 4 | 14.12d | 9d |  |
| 15 | 1.8 | Tagrender |  | 5h | 2007-10-02 | 2007-10-02 | 14, 13SS | 5.12d | 0d |  |
| 16 | 1.9 | Maling udvendigt |  | 10h | 2007-10-02 | 2007-10-03 | 15 | 5.12d | 0d |  |
| 17 | 1.10 | Gulv |  | 1d | 2007-10-03 | 2007-10-04 | 16 | 5.12d |  |  |
| 18 | 1.11 | Maling indvendigt |  | 2d | 2007-10-12 | 2007-10-15 | 17, 12FF | 0d |  |  |
| 19 | 1.12 | Indvielse | milestone | 0d | 2007-10-15 | 2007-10-15 | 18 | 0d |  |  |
