# Butik i Århus

Schedule from MS Project, 2007-09-10 to 2007-10-16, costs in kr.
VideoBuster A/S
Projektplan over byggeriet af den nye butik i Århus. Butikken forventes klar til indvielse om to måneder.

## Calendars

- Standard: Mon-Fri 08:00-12:00, 13:00-17:00; Sat-Sun off.

## Schedule

| ID | WBS | Task | Type | Duration | Start | Finish | Predecessors | Total slack | Free slack | Cost |
| --- | --- | --- | --- | --- | --- | --- | --- | --- | --- | --- |
| 1 | 1 | **Ny butik i Århus** |  | 26.25d | 2007-09-10 | 2007-10-16 |  | 0d |  | 36,000 |
| 2 | 1.1 | Tegning |  | 3d | 2007-09-10 | 2007-09-12 |  | 0d |  |  |
| 3 | 1.2 | **Fundament** |  | 6d | 2007-09-17 | 2007-09-24 | 2FS+2d | 0d |  | 1,000 |
| 4 | 1.2.1 | Udgravning |  | 2d | 2007-09-17 | 2007-09-18 |  | 0d |  |  |
| 5 | 1.2.2 | Støbning |  | 1d | 2007-09-19 | 2007-09-19 | 4 | 0d |  | 1,000 |
| 6 | 1.2.3 | Afbinding |  | 5ed | 2007-09-19 | 2007-09-24 | 5 | 1.88d |  |  |
| 7 | 1.3 | **Råhus** |  | 4.25d | 2007-09-25 | 2007-10-01 | 6 | 0d |  | 35,000 |
| 8 | 1.3.1 | Bærende konstruktioner |  | 3d | 2007-09-25 | 2007-09-27 |  | 0d |  |  |
| 9 | 1.3.2 | Ydervægge |  | 2d | 2007-09-27 | 2007-10-01 | 8FS-2.5% | 0d |  | 15,000 |
| 10 | 1.3.3 | Tag |  | 2d | 2007-09-27 | 2007-10-01 | 9SS | 0d |  | 20,000 |
| 11 | 1.4 | Rejsegilde | milestone | 0d | 2007-10-01 | 2007-10-01 | 10, 9 | 0d |  |  |
| 12 | 1.5 | Taglægning |  | 10d | 2007-10-01 | 2007-10-15 | 11 | 0d |  |  |
| 13 | 1.6 | Døre og vinduer |  | 2d | 2007-10-01 | 2007-10-03 | 12SS | 5.75d | 0d |  |
| 14 | 1.7 | Faskine |  | 2d | 2007-09-19 | 2007-09-20 | 4 | 12.12d | 7d |  |
| 15 | 1.8 | Tagrender |  | 5h | 2007-10-01 | 2007-10-01 | 14, 13SS | 5.75d | 0d |  |
| 16 | 1.9 | Maling udvendigt |  | 10h | 2007-10-01 | 2007-10-03 | 15 | 5.75d | 0d |  |
| 17 | 1.10 | Gulv |  | 1d | 2007-10-02 | 2007-10-03 | 16FS-5% | 5.75d |  |  |
| 18 | 1.11 | Maling indvendigt |  | 2d | 2007-10-11 | 2007-10-15 | 17, 12FF | 0d |  |  |
| 19 | 1.12 | Indvielse | milestone | 0d | 2007-10-16 | 2007-10-16 | 18FS+1d, 13 | 0d |  |  |
