# Butik i Århus

Schedule from MS Project, 2007-09-10 to 2007-10-16, costs in kr.
VideoBuster A/S
Projektplan over byggeriet af den nye butik i Århus. Butikken forventes klar til indvielse om to måneder.

## Calendars

- Standard: Mon-Fri 08:00-12:00, 13:00-17:00; Sat-Sun off.

## Resources

| Resource | Rate | Cost per use | Notes |
| --- | --- | --- | --- |
| Arkitekt Arne | 600 |  |  |
| Murer Mads | 472.5 |  | Der er indgående aftale om lønstigning på 5% med virkning fra 1 måned fra projektets startdato. |
| Jord og beton Jette | 420 |  | Der er indgående aftale om lønstigning på 5% med virkning fra 1 måned fra projektets startdato. |
| Tømrer Tom | 475 |  |  |
| Snedker Susanne | 475 |  |  |
| Maler Morten | 472.5 |  | Der er indgående aftale om lønstigning på 5% med virkning fra 1 måned fra projektets startdato. |
| VVS Victoria | 472.5 |  | Der er indgående aftale om lønstigning på 5% med virkning fra 1 måned fra projektets startdato. |
| Gravemaskine | 600 | 2000 |  |
| Betonblander | 150 | 1200 |  |

## Schedule

| ID | WBS | Task | Type | Duration | Start | Finish | Predecessors | Total slack | Free slack | Resources | Work | Cost |
| --- | --- | --- | --- | --- | --- | --- | --- | --- | --- | --- | --- | --- |
| 1 | 1 | **Ny butik i Århus** |  | 26d | 2007-09-10 | 2007-10-16 |  | 0d |  |  | 255h | 162,860 |
| 2 | 1.1 | Tegning |  | 3d | 2007-09-10 | 2007-09-14 |  | 0d |  | Arkitekt Arne | 24h | 14,400 |
| 3 | 1.2 | **Fundament** |  | 6d | 2007-09-14 | 2007-09-24 | 2 | 0d |  |  | 24h | 14,550 |
| 4 | 1.2.1 | Udgravning |  | 2d | 2007-09-14 | 2007-09-18 |  | 0d |  | Jord og beton Jette; Gravemaskine | 16h | 9,000 |
| 5 | 1.2.2 | Støbning |  | 1d | 2007-09-18 | 2007-09-19 | 4 | 0d |  | Jord og beton Jette; Betonblander | 8h | 5,550 |
| 6 | 1.2.3 | Afbinding |  | 5ed | 2007-09-19 | 2007-09-24 | 5 | 0d |  |  |  |  |
| 7 | 1.3 | **Råhus** |  | 4.5d | 2007-09-24 | 2007-10-01 | 6 | 0d |  |  | 56h | 61,200 |
| 8 | 1.3.1 | Bærende konstruktioner |  | 3d | 2007-09-24 | 2007-09-27 |  | 0d |  | Tømrer Tom | 24h | 11,400 |
| 9 | 1.3.2 | Ydervægge |  | 2d | 2007-09-27 | 2007-09-28 | 8FS-2.5% | 0d |  | Murer Mads | 16h | 22,200 |
| 10 | 1.3.3 | Tag |  | 2d | 2007-09-27 | 2007-10-01 | 9SS | 0d |  | Snedker Susanne | 16h | 27,600 |
| 11 | 1.4 | Rejsegilde | milestone | 0d | 2007-10-01 | 2007-10-01 | 10, 9 | 0d |  | Arkitekt Arne; Jord og beton Jette; Maler Morten; Murer Mads; Snedker Susanne; Tømrer Tom; VVS Victoria |  |  |
| 12 | 1.5 | Taglægning |  | 10d | 2007-10-01 | 2007-10-15 | 11 | 0d |  | Tømrer Tom | 80h | 38,000 |
| 13 | 1.6 | Døre og vinduer |  | 2d | 2007-10-01 | 2007-10-03 | 12SS | 4.5d | 0d | Snedker Susanne | 16h | 7,600 |
| 14 | 1.7 | Faskine |  | 2d | 2007-09-19 | 2007-09-21 | 5 | 11.12d |  | Jord og beton Jette; Gravemaskine | 16h | 9,000 |
| 15 | 1.8 | Tagrender |  | 5h | 2007-10-01 | 2007-10-01 | 14, 13SS | 5.62d | 0d | VVS Victoria | 5h | 2,250 |
| 16 | 1.9 | Maling udvendigt |  | 10h | 2007-10-01 | 2007-10-03 | 15 | 5.62d | 0d | Maler Morten | 10h | 4,500 |
| 17 | 1.10 | Gulv |  | 1d | 2007-10-03 | 2007-10-04 | 16FS-5%, 13 | 4.62d |  | Snedker Susanne | 8h | 3,800 |
| 18 | 1.11 | Maling indvendigt |  | 2d | 2007-10-11 | 2007-10-15 | 17, 12FF | 0d |  | Maler Morten | 16h | 7,560 |
| 19 | 1.12 | Indvielse | milestone | 0d | 2007-10-16 | 2007-10-16 | 18FS+1d, 13 | 0d |  | Arkitekt Arne; Jord og beton Jette; Maler Morten; Murer Mads; Snedker Susanne; Tømrer Tom; VVS Victoria |  |  |
