# Butik i Århus

Schedule from MS Project, 2007-09-10 to 2007-10-18, costs in kr, A marks actual dates.
VideoBuster A/S
Projektplan over byggeriet af den nye butik i Århus. Butikken forventes klar til indvielse om to måneder.

## Calendars

- Standard: Mon-Fri 08:00-12:00, 13:00-17:00; Sat-Sun off.

## Resources

| Resource | Rate | Cost per use | Notes |
| --- | --- | --- | --- |
| Arkitekt Arne | 600 |  |  |
| Murer Mads | 472.5 |  | Der er indgående aftale om lønstigning på 5% med virkning fra 1 måned fra projektets startdato. |
| Jord og beton Jette | 420 |  | Der er indgående aftale om lønstigning på 5% med virkning fra 1 måned fra projektets startdato. |
| Tømrer Tom | 475 |  |  |
| Snedker Susanne | 475 |  |  |
| Maler Morten | 472.5 |  | Der er indgående aftale om lønstigning på 5% med virkning fra 1 måned fra projektets startdato. |
| VVS Victoria | 472.5 |  | Der er indgående aftale om lønstigning på 5% med virkning fra 1 måned fra projektets startdato. |
| Gravemaskine | 600 | 2000 |  |
| Betonblander | 150 | 1200 |  |

## Schedule

| ID | WBS | Task | Type | Duration | Start | Finish | Predecessors | Complete | Baseline start | Baseline finish | Baseline duration | Resources | Work | Actual work | Cost | Baseline cost | Actual cost |
| --- | --- | --- | --- | --- | --- | --- | --- | --- | --- | --- | --- | --- | --- | --- | --- | --- | --- |
| 1 | 1 | **Ny butik i Århus** |  | 28.38d | 2007-09-10 A | 2007-10-18 A |  | 100% | 2007-09-10 | 2007-10-16 | 26d |  | 291h | 291h | 179,960 | 162,860 | 179,960 |
| 2 | 1.1 | Tegning |  | 3d | 2007-09-10 A | 2007-09-14 A |  | 100% | 2007-09-10 | 2007-09-14 | 3d | Arkitekt Arne | 24h | 24h | 14,400 | 14,400 | 14,400 |
| 3 | 1.2 | **Fundament** |  | 6d | 2007-09-14 A | 2007-09-24 A | 2 | 100% | 2007-09-14 | 2007-09-24 | 6d |  | 24h | 24h | 14,550 | 14,550 | 14,550 |
| 4 | 1.2.1 | Udgravning |  | 2d | 2007-09-14 A | 2007-09-18 A |  | 100% | 2007-09-14 | 2007-09-18 | 2d | Jord og beton Jette; Gravemaskine | 16h | 16h | 9,000 | 9,000 | 9,000 |
| 5 | 1.2.2 | Støbning |  | 1d | 2007-09-18 A | 2007-09-19 A | 4 | 100% | 2007-09-18 | 2007-09-19 | 1d | Jord og beton Jette; Betonblander | 8h | 8h | 5,550 | 5,550 | 5,550 |
| 6 | 1.2.3 | Afbinding |  | 5ed | 2007-09-19 A | 2007-09-24 A | 5 | 100% | 2007-09-19 | 2007-09-24 | 5ed |  |  |  |  |  |  |
| 7 | 1.3 | **Råhus** |  | 4.88d | 2007-09-24 A | 2007-10-01 A | 6 | 100% | 2007-09-24 | 2007-10-01 | 4.5d |  | 60h | 60h | 63,100 | 61,200 | 63,100 |
| 8 | 1.3.1 | Bærende konstruktioner |  | 3.5d | 2007-09-24 A | 2007-09-28 A |  | 100% | 2007-09-24 | 2007-09-27 | 3d | Tømrer Tom | 28h | 28h | 13,300 | 11,400 | 13,300 |
| 9 | 1.3.2 | Ydervægge |  | 2d | 2007-09-27 A | 2007-10-01 A | 8FS-2.5% | 100% | 2007-09-27 | 2007-09-28 | 2d | Murer Mads | 16h | 16h | 22,200 | 22,200 | 22,200 |
| 10 | 1.3.3 | Tag |  | 2d | 2007-09-27 A | 2007-10-01 A | 9SS | 100% | 2007-09-27 | 2007-10-01 | 2d | Snedker Susanne | 16h | 16h | 27,600 | 27,600 | 27,600 |
| 11 | 1.4 | Rejsegilde | milestone | 0d | 2007-10-01 A | 2007-10-01 A | 10, 9 | 100% | 2007-10-01 | 2007-10-01 | 0d | Arkitekt Arne; Jord og beton Jette; Maler Morten; Murer Mads; Snedker Susanne; Tømrer Tom; VVS Victoria |  |  |  |  |  |
| 12 | 1.5 | Taglægning |  | 12d | 2007-10-01 A | 2007-10-17 A | 11 | 100% | 2007-10-01 | 2007-10-15 | 10d | Tømrer Tom | 96h | 96h | 45,600 | 38,000 | 45,600 |
| 13 | 1.6 | Døre og vinduer |  | 4d | 2007-10-01 A | 2007-10-08 A | 12SS | 100% | 2007-10-01 | 2007-10-03 | 2d | Snedker Susanne | 32h | 32h | 15,200 | 7,600 | 15,200 |
| 14 | 1.7 | Faskine |  | 2d | 2007-09-19 A | 2007-09-21 A | 5 | 100% | 2007-09-19 | 2007-09-21 | 2d | Jord og beton Jette; Gravemaskine | 16h | 16h | 9,000 | 9,000 | 9,000 |
| 15 | 1.8 | Tagrender |  | 5h | 2007-10-01 A | 2007-10-02 A | 14, 13SS | 100% | 2007-10-01 | 2007-10-01 | 5h | VVS Victoria | 5h | 5h | 2,250 | 2,250 | 2,250 |
| 16 | 1.9 | Maling udvendigt |  | 10h | 2007-10-02 A | 2007-10-03 A | 15 | 100% | 2007-10-01 | 2007-10-03 | 10h | Maler Morten | 10h | 10h | 4,500 | 4,500 | 4,500 |
| 17 | 1.10 | Gulv |  | 1d | 2007-10-08 A | 2007-10-09 A | 16FS-5%, 13 | 100% | 2007-10-03 | 2007-10-04 | 1d | Snedker Susanne | 8h | 8h | 3,800 | 3,800 | 3,800 |
| 18 | 1.11 | Maling indvendigt |  | 2d | 2007-10-15 A | 2007-10-17 A | 17, 12FF | 100% | 2007-10-11 | 2007-10-15 | 2d | Maler Morten | 16h | 16h | 7,560 | 7,560 | 7,560 |
| 19 | 1.12 | Indvielse | milestone | 0d | 2007-10-18 A | 2007-10-18 A | 18FS+1d, 13 | 100% | 2007-10-16 | 2007-10-16 | 0d | Arkitekt Arne; Jord og beton Jette; Maler Morten; Murer Mads; Snedker Susanne; Tømrer Tom; VVS Victoria |  |  |  |  |  |
