# Repetition7

Schedule from MS Project, 2007-09-04 to 2007-12-27, costs in kr.
Petfood Inc,

## Calendars

- Standard: Mon-Fri 08:00-12:00, 13:00-17:00; Sat-Sun off.

## Resources

| Resource | Rate | Cost per use | Notes |
| --- | --- | --- | --- |
| Arkitekt Arne | 500 |  |  |
| Murer Morten | 450 |  |  |
| Jord og Beton Jette | 450 |  |  |
| Tømrer Tom | 495 |  | Der er indgået aftale med Tømrer Tom om lønregulering på 10% af både standardsats og overtidssats pr. xx-xx-xxxx. |
| Snedker Susanne | 450 |  |  |
| Maler Mikkel | 450 |  |  |
| VVS Viktoria | 450 |  |  |
| El Erik | 450 |  |  |
| Gravemaskine | 200 | 1500 |  |
| Stillads | 50 |  |  |
| Betonblander | 125 | 750 |  |
| Peter Brixtofte |  |  |  |

## Schedule

| ID | WBS | Task | Type | Duration | Start | Finish | Predecessors | Total slack | Free slack | Resources | Work | Cost |
| --- | --- | --- | --- | --- | --- | --- | --- | --- | --- | --- | --- | --- |
| 1 | 1 | **Byggeprojekt** |  | 83d | 2007-09-04 | 2007-12-27 |  | 0d |  |  | 813h | 336,650 |
| 2 | 1.1 | **Tegninger** |  | 38d | 2007-09-04 | 2007-10-25 |  | 0d |  |  | 280h | 140,000 |
| 3 | 1.1.1 | Myndighedstegninger |  | 15d | 2007-09-04 | 2007-09-25 |  | 0d |  | Arkitekt Arne | 120h | 60,000 |
| 4 | 1.1.2 | **Detailtegninger** |  | 20d | 2007-09-28 | 2007-10-25 |  | 0d |  |  | 160h | 80,000 |
| 5 | 1.1.2.1 | Beton og murværk |  | 5d | 2007-09-28 | 2007-10-04 | 3FS+2d | 0d |  | Arkitekt Arne | 40h | 20,000 |
| 6 | 1.1.2.2 | Trækonstruktioner |  | 5d | 2007-10-05 | 2007-10-11 | 5 | 0d |  | Arkitekt Arne | 40h | 20,000 |
| 7 | 1.1.2.3 | Øvrige |  | 10d | 2007-10-12 | 2007-10-25 | 6 | 0d |  | Arkitekt Arne | 80h | 40,000 |
| 8 | 1.2 | **Offentlige myndigheder** |  | 15d | 2007-10-26 | 2007-11-15 |  | 0d |  |  | 200h | 40,000 |
| 9 | 1.2.1 | Byggegodkendelse |  | 10d | 2007-10-26 | 2007-11-08 | 7 | 0d |  | Arkitekt Arne | 80h | 40,000 |
| 10 | 1.2.2 | Budgetgodkendelse |  | 15d | 2007-10-26 | 2007-11-15 | 9SS | 0d |  | Peter Brixtofte | 120h |  |
| 11 | 1.3 | **Fundament** |  | 10d | 2007-11-16 | 2007-11-29 |  | 0d |  |  | 32h | 14,400 |
| 12 | 1.3.1 | Udgravning |  | 3d | 2007-11-16 | 2007-11-20 | 10 | 0d |  | Jord og Beton Jette | 24h | 10,800 |
| 13 | 1.3.2 | Støbning |  | 1d | 2007-11-21 | 2007-11-21 | 12 | 0d |  | Jord og Beton Jette | 8h | 3,600 |
| 14 | 1.3.3 | Afbinding |  | 6d | 2007-11-22 | 2007-11-29 | 13 | 0d |  |  |  |  |
| 15 | 1.4 | Murværk |  | 5d | 2007-11-30 | 2007-12-06 | 14 | 0d |  | Murer Morten | 40h | 18,000 |
| 16 | 1.5 | Tagkonstruktion |  | 2d | 2007-12-07 | 2007-12-10 | 15 | 0d |  | Tømrer Tom | 16h | 7,920 |
| 17 | 1.6 | Rejsegilde | milestone | 0d | 2007-12-10 | 2007-12-10 | 16 | 0d |  |  |  | 5,000 |
| 18 | 1.7 | Taglægning |  | 2d | 2007-12-11 | 2007-12-12 | 17 | 7.75d | 0d | Tømrer Tom | 16h | 7,920 |
| 19 | 1.8 | **Tagrender** |  | 16.25d | 2007-11-22 | 2007-12-14 |  | 9.75d |  |  | 26h | 12,060 |
| 20 | 1.8.1 | Udgravning af faskine |  | 2d | 2007-11-22 | 2007-11-23 | 13 | 22.75d | 13d | Jord og Beton Jette | 16h | 7,200 |
| 21 | 1.8.2 | Montering af render og afløb |  | 1d | 2007-12-13 | 2007-12-13 | 18, 20 | 7.75d | 0d | Tømrer Tom | 8h | 3,960 |
| 22 | 1.8.3 | Tilslutning |  | 0.25d | 2007-12-14 | 2007-12-14 | 21 | 7.75d |  | Jord og Beton Jette | 2h | 900 |
| 23 | 1.9 | Døre og vinduer |  | 2d | 2007-12-11 | 2007-12-12 | 17 | 0d |  | Snedker Susanne | 16h | 7,200 |
| 24 | 1.10 | Udvendig maling |  | 4d | 2007-12-13 | 2007-12-18 | 23 | 5d |  | Maler Mikkel | 32h | 14,400 |
| 25 | 1.11 | Indvendige skillevægge |  | 3d | 2007-12-13 | 2007-12-17 | 17, 23 | 0d |  | Snedker Susanne | 24h | 10,800 |
| 26 | 1.12 | Gulv |  | 2d | 2007-12-18 | 2007-12-19 | 25 | 0d |  | Snedker Susanne | 16h | 7,200 |
| 27 | 1.13 | Indvendige døre - montering |  | 0.38d | 2007-12-20 | 2007-12-20 | 26 | 5.62d |  | Snedker Susanne | 3h | 1,350 |
| 28 | 1.14 | VVS |  | 4d | 2007-12-20 | 2007-12-25 | 26 | 2d |  | VVS Viktoria | 32h | 14,400 |
| 29 | 1.15 | El |  | 6d | 2007-12-20 | 2007-12-27 | 26 | 0d |  | El Erik | 48h | 21,600 |
| 30 | 1.16 | Indvendig maling |  | 4d | 2007-12-20 | 2007-12-25 | 26, 24 | 2d |  | Maler Mikkel | 32h | 14,400 |
| 31 | 1.17 | Indvielse | milestone | 0d | 2007-12-27 | 2007-12-27 | 22, 24, 27, 28, 29, 30 | 0d |  |  |  |  |
