# Butik i Århus

Schedule from MS Project, 2007-09-10 to 2007-10-16, costs in kr.
VideoBuster A/S
Projektplan over byggeriet af den nye butik i Århus. Butikken forventes klar til indvielse om to måneder.

## Calendars

- Standard: Mon-Fri 08:00-12:00, 13:00-17:00; Sat-Sun off.

## Resources

| Resource | Unit | Rate |
| --- | --- | --- |
| Arkitekt Arne |  | 600 |
| Murer Mads |  | 472.5 |
| Jord og beton Jette |  | 420 |
| Tømrer Tom |  | 475 |
| Snedker Susanne |  | 475 |
| Maler Morten |  | 472.5 |
| VVS Victoria |  | 472.5 |
| Cement | Sække | 175 |
| Lægter | Meter | 35 |
| Søm | Pakker | 65 |
| Transport |  |  |
| Overnatning |  |  |

## Schedule

| ID | WBS | Task | Type | Duration | Start | Finish | Predecessors | Total slack | Free slack | Resources | Work | Cost |
| --- | --- | --- | --- | --- | --- | --- | --- | --- | --- | --- | --- | --- |
| 1 | 1 | **Ny butik i Århus** |  | 27d | 2007-09-10 | 2007-10-16 |  | 0d |  |  | 247h | 161,800 |
| 2 | 1.1 | Tegning |  | 3d | 2007-09-10 | 2007-09-12 |  | 0d |  | Arkitekt Arne; Transport [0.2%]; Overnatning [1%] | 24h | 17,275 |
| 3 | 1.2 | **Fundament** |  | 6d | 2007-09-17 | 2007-09-24 | 2FS+2d | 0d |  |  | 16h | 8,625 |
| 4 | 1.2.1 | Udgravning |  | 2d | 2007-09-17 | 2007-09-18 |  | 0d |  | Jord og beton Jette | 16h | 6,400 |
| 5 | 1.2.2 | Støbning |  | 1d | 2007-09-19 | 2007-09-19 | 4 | 0d |  | Cement [7 Sække] |  | 2,225 |
| 6 | 1.2.3 | Afbinding |  | 5ed | 2007-09-19 | 2007-09-24 | 5 | 1.88d |  |  |  |  |
| 7 | 1.3 | **Råhus** |  | 5d | 2007-09-25 | 2007-10-01 | 6 | 0d |  |  | 56h | 65,790 |
| 8 | 1.3.1 | Bærende konstruktioner |  | 3d | 2007-09-25 | 2007-09-27 |  | 0d |  | Tømrer Tom; Lægter [120 Meter]; Søm [6 Pakker] | 24h | 15,990 |
| 9 | 1.3.2 | Ydervægge |  | 2d | 2007-09-28 | 2007-10-01 | 8 | 0d |  | Murer Mads | 16h | 22,200 |
| 10 | 1.3.3 | Tag |  | 2d | 2007-09-28 | 2007-10-01 | 9SS | 0d |  | Tømrer Tom | 16h | 27,600 |
| 11 | 1.4 | Rejsegilde | milestone | 0d | 2007-10-01 | 2007-10-01 | 10, 9 | 0d |  |  |  |  |
| 12 | 1.5 | Taglægning |  | 10d | 2007-10-02 | 2007-10-15 | 11 | 0d |  | Tømrer Tom | 80h | 38,000 |
| 13 | 1.6 | Døre og vinduer |  | 2d | 2007-10-02 | 2007-10-04 | 12SS | 4.5d | 0d | Snedker Susanne | 16h | 7,600 |
| 14 | 1.7 | Faskine |  | 2d | 2007-09-20 | 2007-09-21 | 5 | 10.88d | 6d | Jord og beton Jette | 16h | 6,400 |
| 15 | 1.8 | Tagrender |  | 5h | 2007-10-02 | 2007-10-02 | 14, 13SS | 4.88d | 0d | Murer Mads | 5h | 2,250 |
| 16 | 1.9 | Maling udvendigt |  | 10h | 2007-10-02 | 2007-10-03 | 15 | 4.88d | 0.38d | Maler Morten | 10h | 4,500 |
| 17 | 1.10 | Gulv |  | 1d | 2007-10-04 | 2007-10-05 | 16, 13 | 4.5d | 4.62d | Snedker Susanne | 8h | 3,800 |
| 18 | 1.11 | Maling indvendigt |  | 2d | 2007-10-12 | 2007-10-15 | 17, 12FF | 0d |  | Maler Morten | 16h | 7,560 |
| 19 | 1.12 | Indvielse | milestone | 0d | 2007-10-16 | 2007-10-16 | 18FS+1d, 13 | 0d |  |  |  |  |
